# correction ex blanc

Schedule from MS Project, 2016-12-01 to 2017-01-19, costs in $.

## Calendars

- Standard: Mon-Fri 08:00-12:00, 13:00-17:00; Sat-Sun off.

## Resources

| Resource | Rate |
| --- | --- |
| Chris | 100 |
| Nagi | 100 |
| Hani | 75 |
| Joe | 50 |
| Expert | 187.5 |
| Avocat | 375 |

## Schedule

| ID | WBS | Task | Type | Duration | Start | Finish | Predecessors | Total slack | Constraint | Deadline | Resources | Work | Cost |
| --- | --- | --- | --- | --- | --- | --- | --- | --- | --- | --- | --- | --- | --- |
| 1 | 1 | **Analyse et Réflexion** |  | 10d | 2016-12-01 | 2016-12-14 |  | 0d |  |  |  | 152h | 15,300 |
| 2 | 1.1 | Cahier de Charge |  | 4d | 2016-12-01 | 2016-12-06 |  | 0d |  |  | Chris | 32h | 3,200 |
| 3 | 1.2 | Schéma |  | 4d | 2016-12-07 | 2016-12-12 | 2 | 0d |  |  | Chris; Nagi | 64h | 6,400 |
| 4 | 1.3 | Réunion des 4 |  | 1d | 2016-12-13 | 2016-12-13 | 3 | 0d |  |  | Chris; Hani; Joe; Nagi | 32h | 2,600 |
| 5 | 1.4 | Réunion expert |  | 1d | 2016-12-14 | 2016-12-14 | 4 | 0d |  |  | Chris; Expert; Nagi | 24h | 3,100 |
| 6 | 1.5 | Milestone 1 | milestone | 0d | 2016-12-14 | 2016-12-14 | 5 | 0d |  |  |  |  |  |
| 7 | 2 | **Structure de la société** |  | 11d | 2016-12-15 | 2016-12-29 | 1 | 0d |  |  |  | 208h | 43,000 |
| 8 | 2.1 | Réunion avec l'avocat |  | 1d | 2016-12-15 | 2016-12-15 |  | 0d |  |  | Avocat; Chris; Nagi | 24h | 4,600 |
| 9 | 2.2 | Fondation |  | 2d | 2016-12-23 | 2016-12-26 | 8FS+1w | 3d |  |  |  |  | 20,000 |
| 10 | 2.3 | Installation Locaux |  | 10d | 2016-12-16 | 2016-12-29 | 8 | 0d |  |  | Chris; Nagi | 160h | 16,000 |
| 11 | 2.4 | Ecriture Bus. Plan |  | 3d | 2016-12-27 | 2016-12-29 | 10FF | 0d |  |  | Chris | 24h | 2,400 |
| 12 | 2.5 | Milestone 2 | milestone | 0d | 2016-12-29 | 2016-12-29 | 9, 11 | 0d |  |  |  |  |  |
| 13 | 3 | **Développement** |  | 15d | 2016-12-30 | 2017-01-19 | 7 | 0d |  |  |  | 240h | 18,000 |
| 14 | 3.1 | App iPhone |  | 2w | 2016-12-30 | 2017-01-12 |  | 0d | start no earlier than 2016-12-25 |  | Hani; Joe | 160h | 10,000 |
| 15 | 3.2 | App Android |  | 2w | 2017-01-06 | 2017-01-19 | 14SS+1w | 0d |  |  | Nagi | 80h | 8,000 |
| 16 | 3.3 | Milestone 3 | milestone | 0d | 2017-01-19 | 2017-01-19 | 14, 15 | 0d |  | 2017-01-31 |  |  |  |

Notes:
- 16: le cout total est de 76300
